# Piraten-Kommunalwahlkampf Hessen

Schedule from Planner, 2010-11-06 to 2011-04-11.
Piratenpartei Hessen

## Calendars

- Vorgabe: Mon-Fri 08:00-12:00, 13:00-17:00; Sat-Sun off.

## Schedule

| ID | WBS | Task | Type | Duration | Start | Finish | Predecessors | Complete | Constraint | Work |
| --- | --- | --- | --- | --- | --- | --- | --- | --- | --- | --- |
| 1 | 1 | HELP10.x | milestone | 0d | 2010-11-08 | 2010-11-06 |  |  | must start on 2010-11-06 |  |
| 2 | 2 | **Kreisparteitage** |  |  | 2010-11-08 | 2010-12-24 | 1 |  |  | 304h |
| 3 | 2.1 | Zeitraum für KPT's |  |  | 2010-11-08 | 2010-12-24 |  |  |  | 280h |
| 4 | 2.2 | Wahlvorschlag für Wahlkreis |  |  | 2010-11-08 | 2010-11-08 |  |  |  | 8h |
| 5 | 2.3 | Eidesstattliche Erklärungen geheime Wahl |  |  | 2010-11-08 | 2010-11-08 |  |  |  | 8h |
| 6 | 2.4 | Protokoll der Versammlung |  |  | 2010-11-08 | 2010-11-08 |  |  |  | 8h |
| 7 | 3 | **Wahlvorschlag / Kandidaten Liste** |  |  | 2010-11-08 | 2011-01-14 |  |  |  | 136h |
| 8 | 3.1 | Schriftliche Zustimmung der Bewerber zur Wahl |  |  | 2010-11-08 | 2010-11-08 |  |  |  | 8h |
| 9 | 3.2 | Bescheinigung der Wählbarkeit |  |  | 2010-11-08 | 2010-11-08 |  |  |  | 8h |
| 10 | 3.3 | Sammlung UU's |  |  | 2010-12-27 | 2011-01-13 | 2 |  |  | 112h |
| 11 | 3.4 | Abgabe Unterstützerunterschriften |  |  | 2011-01-14 | 2011-01-14 | 10 | 46% | must start on 2011-01-14 | 8h |
| 12 | 4 | **Wahlkampfmaterial Hessen** |  |  | 2010-11-08 | 2010-12-21 |  |  |  | 336h |
| 13 | 4.1 | Inhalte festlegen |  |  | 2010-11-08 | 2010-11-08 | 1 |  |  | 8h |
| 14 | 4.2 | Flyer texten |  |  | 2010-11-09 | 2010-11-26 | 13 |  |  | 112h |
| 15 | 4.3 | Layout |  |  | 2010-11-15 | 2010-12-02 | 14FS-288h |  |  | 112h |
| 16 | 4.4 | Druck |  |  | 2010-12-03 | 2010-12-16 | 15 |  |  | 80h |
| 17 | 4.5 | Verteilung |  |  | 2010-12-17 | 2010-12-21 | 16 |  |  | 24h |
| 18 | 5 | **Wahlkampfmaterial Kommunal** |  |  | 2010-12-27 | 2011-02-03 |  |  |  | 312h |
| 19 | 5.1 | Inhalte festlegen |  |  | 2010-12-27 | 2010-12-27 | 2 | 100% |  | 8h |
| 20 | 5.2 | Flyer texten |  |  | 2010-12-28 | 2011-01-14 | 19 |  |  | 112h |
| 21 | 5.3 | Layout |  |  | 2011-01-03 | 2011-01-20 | 20FS-336h |  |  | 112h |
| 22 | 5.4 | Druck |  |  | 2011-01-21 | 2011-02-03 | 21 |  |  | 80h |
| 23 | 6 | **Wahlkampf** |  |  | 2011-01-31 | 2011-03-28 |  |  |  | 88h |
| 24 | 6.1 | Plakatieren |  |  | 2011-01-31 | 2011-02-02 |  |  | must start on 2011-01-31 | 24h |
| 25 | 6.2 | Auftakt_Geb LV HE | milestone | 0d | 2011-02-16 | 2011-02-16 |  |  | must start on 2011-02-16 |  |
| 26 | 6.3 | Infostand 02-19 |  |  | 2011-02-21 | 2011-02-21 |  |  | must start on 2011-02-19 | 8h |
| 27 | 6.4 | Infostand 02-26 |  |  | 2011-02-28 | 2011-02-28 |  |  | must start on 2011-02-26 | 8h |
| 28 | 6.5 | Infostand 3-05 |  |  | 2011-03-07 | 2011-03-07 |  |  | must start on 2011-03-05 | 8h |
| 29 | 6.6 | Infostand 3-12 |  |  | 2011-03-14 | 2011-03-14 |  |  | must start on 2011-03-12 | 8h |
| 30 | 6.7 | Infostand 3-19 |  |  | 2011-03-21 | 2011-03-21 |  |  | must start on 2011-03-19 | 8h |
| 31 | 6.8 | Infostand 3-24 |  |  | 2011-03-24 | 2011-03-24 |  |  | must start on 2011-03-24 | 8h |
| 32 | 6.9 | Infostand 3-25 |  |  | 2011-03-25 | 2011-03-25 |  |  | must start on 2011-03-25 | 8h |
| 33 | 6.10 | Infostand 3-26 |  |  | 2011-03-28 | 2011-03-28 |  |  | must start on 2011-03-26 | 8h |
| 34 | 7 | Wahlparty | milestone | 0d | 2011-03-28 | 2011-03-27 |  |  | must start on 2011-03-27 |  |
| 35 | 8 | Abplakatieren |  |  | 2011-03-28 | 2011-03-31 |  |  | start no earlier than 2011-03-27 | 32h |
| 36 | 9 | Feedback - Veranstaltung |  |  | 2011-04-11 | 2011-04-11 |  |  | must start on 2011-04-09 | 8h |
